# First DESP deployment

Schedule from MS Project, 2009-03-20 to 2009-04-14, 9 hours a day, A marks actual dates.

## Calendars

- Standard: Mon-Thu 07:30-12:00, 13:00-17:30; Fri 08:00-12:00, 13:00-17:00; Sat-Sun off. Exceptions (off unless hours are given): 2009-03-27 (Friday off), 2009-04-10 (Friday off).

## Resources

| Resource |
| --- |
| Jose |
| Mike C |
| Mike P |
| ME tech |
| Doug |
| Jim |
| Scott |
| Wayne |
| All |
| Brent |
| cheri |
| doug/scott |
| doug/mike |
| doug/brent |

## Schedule

| ID | WBS | Task | Duration | Start | Finish | Predecessors | Complete | Remaining | Total slack | Free slack | Constraint | Resources | Work | Actual work |
| --- | --- | --- | --- | --- | --- | --- | --- | --- | --- | --- | --- | --- | --- | --- |
| 1 | 1 | **Elevator stuff** | 9.94d? | 2009-03-20 A | 2009-04-06 |  | 25% | 7.45d? | 5.78d |  |  |  | 395.01h | 94.68h |
| 2 | 1.1 | Mount Foam to Elevator Ring | 1d | 2009-03-30 | 2009-03-31 |  |  |  | 0.78d | 0d | start no earlier than 2009-03-30 | Mike C | 9h |  |
| 3 | 1.2 | **Bail ring** | 1d | 2009-03-31 | 2009-04-01 |  |  |  | 0.78d |  |  |  | 17.46h |  |
| 4 | 1.2.1 | design & manufacture | 1d | 2009-03-31 | 2009-04-01 | 2 |  |  | 0.78d | 0d | start no earlier than 2009-03-24 | Mike C | 9h |  |
| 5 | 1.2.2 | mount | 0.94d | 2009-03-31 | 2009-03-31 | 2 |  |  | 0.84d | 0.06d | start no earlier than 2009-03-30 | Mike C | 8.46h |  |
| 6 | 1.2.3 | RF beacon on spar buoy | 9h | 2009-03-31 | 2009-04-01 | 2 |  |  | 0.78d | 0d | start no earlier than 2009-03-30 |  |  |  |
| 7 | 1.3 | **Elevator Hardware** | 9.94d? | 2009-03-20 A | 2009-04-06 |  | 38% | 6.18d? | 5.78d |  |  |  | 195.93h | 69.75h |
| 8 | 1.3.1 | **Mounting foam ring** | 4d | 2009-03-30 A | 2009-04-03 |  | 44% | 2.25d | 1.78d |  |  |  | 36h | 15.75h |
| 9 | 1.3.1.1 | design & manufacture new capture cones | 2d | 2009-03-30 A | 2009-04-01 |  | 25% | 1.5d | 0.95d | 0d | start no earlier than 2009-03-30 | Mike P | 18h | 4.5h |
| 10 | 1.3.1.2 | re-tap mounts | 1d | 2009-04-01 A | 2009-04-02 A | 9 | 100% |  |  |  | start no earlier than 2009-03-31 | Mike P | 9h | 9h |
| 11 | 1.3.1.3 | make new studs | 1d | 2009-04-02 A | 2009-04-03 | 10 | 25% | 0.75d | 1.78d |  | start no earlier than 2009-04-01 | Mike P | 9h | 2.25h |
| 12 | 1.3.2 | **Mounting feet** | 3.78d | 2009-03-24 A | 2009-03-30 |  | 80% | 0.75d | 10d |  |  |  | 25.02h | 25.02h |
| 13 | 1.3.2.1 | Fix cracked welds | 0.89d | 2009-03-24 A | 2009-03-24 A |  | 100% |  |  |  | start no earlier than 2009-03-24 | ME tech | 8.01h | 8.01h |
| 14 | 1.3.2.2 | design feet mounting plates | 0.89d | 2009-03-24 A | 2009-03-25 A | 13 | 100% |  |  |  | start no earlier than 2009-03-24 | ME tech | 8.01h | 8.01h |
| 15 | 1.3.2.3 | make mounting plates | 9h | 2009-03-25 A | 2009-03-26 | 14 | 25% | 6.75h | 11d |  |  |  |  |  |
| 16 | 1.3.2.4 | mount feet | 1d | 2009-03-26 A | 2009-03-30 A | 15 | 100% |  |  |  | start no earlier than 2009-03-24 | ME tech | 9h | 9h |
| 17 | 1.3.3 | **Battery issues** | 6.83d? | 2009-03-25 A | 2009-04-03 |  | 35% | 4.42d? | 5.95d |  |  |  | 62.91h | 22.23h |
| 18 | 1.3.3.1 | design & fabricate battery hold-downs | 1d | 2009-03-30 A | 2009-03-31 | 16 | 50% | 0.5d | 9d |  | start no earlier than 2009-03-25 | ME tech | 9h | 4.5h |
| 19 | 1.3.3.2 | grind gussets so batteries fit elevator | 1d | 2009-03-30 A | 2009-03-31 A | 16 | 100% |  |  |  | start no earlier than 2009-03-30 | ME tech | 9h | 9h |
| 20 | 1.3.3.3 | mount batteries | 1d? | 2009-03-31 | 2009-04-01 | 19 |  |  | -0.05d | 0d | start no earlier than 2009-03-31 | ME tech | 9h |  |
| 21 | 1.3.3.4 | charge batteries | 2.05d | 2009-04-01 | 2009-04-03 | 20 |  |  | -0.05d | 0d | start no earlier than 2009-04-01 | Scott | 18.45h |  |
| 22 | 1.3.3.5 | complete battery combiner box & mount | 1.94d | 2009-03-25 A | 2009-03-26 |  | 50% | 0.97d | 10.84d |  | start no earlier than 2009-03-25 | Jose | 17.46h | 8.73h |
| 23 | 1.3.4 | **Drop weight** | 3d | 2009-04-01 | 2009-04-06 |  |  |  | 0.78d |  |  |  | 27h |  |
| 24 | 1.3.4.1 | design & build drop weight mechanism | 2d | 2009-04-01 | 2009-04-03 | 5, 6, 4 |  |  | 0.78d | 0d | start no earlier than 2009-03-30 | Mike C | 18h |  |
| 25 | 1.3.4.2 | build 240lb drop weight | 1d | 2009-04-03 | 2009-04-06 | 24 |  |  | 0.78d |  | start no earlier than 2009-04-01 | Mike C | 9h |  |

| ID | WBS | Task | Duration | Start | Finish | Predecessors | Complete | Remaining | Total slack | Free slack | Constraint | Resources | Work | Actual work |
| --- | --- | --- | --- | --- | --- | --- | --- | --- | --- | --- | --- | --- | --- | --- |
| 26 | 1.3.5 | **DWSM** | 8.94d? | 2009-03-20 A | 2009-04-03 |  | 29% | 6.34d? | 6.78d |  |  |  | 45h | 6.75h |
| 27 | 1.3.5.1 | purchase oil reservoir bag & mount | 3d | 2009-03-25 A | 2009-03-31 |  | 25% | 2.25d | 9.78d |  | start no earlier than 2009-03-25 | Doug | 27h | 6.75h |
| 28 | 1.3.5.2 | design & manufacture DWSM mounting bracket | 1d | 2009-04-01 | 2009-04-02 | 9 |  |  | 0.95d | 0d | start no earlier than 2009-03-31 | Mike P | 9h |  |
| 29 | 1.3.5.3 | make fluid connection b/w DWSM and Sphere | 1d | 2009-04-02 | 2009-04-03 | 28 |  |  | 0.95d | 0d | start no earlier than 2009-04-01 | Doug | 9h |  |
| 30 | 1.3.5.4 | check availability of beacon/spar | 1d? | 2009-03-20 A | 2009-03-23 A |  | 100% |  |  |  |  |  |  |  |
| 31 | 1.4 | decide on which acoustic modem to order | 4.83d | 2009-03-30 | 2009-04-03 |  |  |  | 5.94d |  | finish no earlier than 2009-04-03 | doug/brent | 43.5h |  |
| 32 | 1.5 | order acoustic modem | 43.5h | 2009-03-30 | 2009-04-03 |  |  |  | 5.94d |  | start no earlier than 2009-03-30 | Brent | 43.5h |  |
| 33 | 1.6 | order modem connectors and cable | 43.5h | 2009-03-30 | 2009-04-03 |  |  |  | 5.94d |  | start no earlier than 2009-03-30 | Scott | 43.5h |  |
| 34 | 1.7 | **wet-mate whip** | 6.88d? | 2009-03-20 A | 2009-03-31 |  | 59% | 2.81d? | 8.84d |  |  |  | 42.12h | 24.93h |
| 35 | 1.7.1 | double-check w/ FOCE about borrowing | 0.8d | 2009-03-20 A | 2009-03-20 A |  | 100% |  |  |  | start no earlier than 2009-03-20 | Jim | 7.2h | 7.2h |
| 36 | 1.7.2 | talk to ROV pilots about design | 1d? | 2009-03-20 A | 2009-03-23 A | 35 | 100% |  |  |  |  | All | 9h | 9h |
| 37 | 1.7.3 | manufacture coil holder to ROV pilots liking | 1.94d? | 2009-03-24 A | 2009-03-30 | 36 | 50% | 0.97d? | 8.92d | 0.09d | start no earlier than 2009-03-24 | ME tech | 17.46h | 8.73h |
| 38 | 1.7.4 | mount on elevator | 0.94d? | 2009-03-31 | 2009-03-31 | 37 |  |  | 8.84d |  | start no earlier than 2009-03-31 | ME tech | 8.46h |  |
| 39 | 2 | **Sphere stuff** | 8.94d? | 2009-03-20 A | 2009-04-03 |  | 39% | 5.45d? | 6.78d |  |  |  | 103.96h | 40.56h |
| 40 | 2.1 | Clean old overpressure valves | 0.89d? | 2009-03-25 A | 2009-03-25 |  | 25% | 0.67d? | 9d | 0d | start no earlier than 2009-03-25 | Doug | 8h | 2h |
| 41 | 2.2 | mount overpressure valves | 0.89d | 2009-03-25 | 2009-03-26 | 40 |  |  | 9d | 2.22d | start no earlier than 2009-03-25 | Doug | 8h |  |
| 42 | 2.3 | finish wiring sphere/ test power supply | 2.83d? | 2009-03-20 A | 2009-03-24 |  | 65% | 1d? | 6.95d | 0.11d | start no earlier than 2009-03-20 | Scott | 25.5h | 16.47h |
| 43 | 2.4 | mount MACK in web | 1d? | 2009-03-24 A | 2009-03-25 A |  | 100% |  |  |  | start no earlier than 2009-03-24 | cheri | 9h | 9h |
| 44 | 2.5 | connect wires from sphere to core | 1.94d? | 2009-03-25 A | 2009-03-26 | 42, 43 | 75% | 0.48d? | 6.84d | 0.06d | start no earlier than 2009-03-25 | Scott | 17.46h | 13.1h |
| 45 | 2.6 | test electrical connections of core within sphere | 1d? | 2009-03-30 | 2009-03-31 | 44 |  |  | 6.78d | 0d | start no earlier than 2009-03-30 | Scott | 9h |  |
| 46 | 2.7 | test wet-mate simm can interface | 1d? | 2009-03-31 | 2009-04-01 | 45 |  |  | 6.78d | 0d |  | Scott | 9h |  |
| 47 | 2.8 | assemble sphere halves together | 1d? | 2009-04-01 | 2009-04-02 | 46, 41 |  |  | 6.78d | 0d |  | Doug | 9h |  |
| 48 | 2.9 | pressure test sphere | 1d? | 2009-04-02 | 2009-04-03 | 47 |  |  | 6.78d |  | finish no earlier than 2009-04-02 | Doug | 9h |  |
| 49 | 3 | **DWSM stuff** | 8.83d? | 2009-03-20 A | 2009-04-02 |  | 30% | 6.15d? | 6.89d |  |  |  | 295.97h | 90.01h |
| 50 | 3.1 | order SS jacket bolts | 1d? | 2009-03-25 | 2009-03-26 |  |  |  | 11.78d |  | start no earlier than 2009-03-25 | Doug | 9h |  |
| 51 | 3.2 | finish dPress CPLD | 0.89d? | 2009-03-20 A | 2009-03-20 A |  | 100% |  |  |  | start no earlier than 2009-03-20 | Wayne | 8h | 8h |
| 52 | 3.3 | test pressure sensors and switches | 3d | 2009-03-23 A | 2009-03-26 | 51 | 75% | 0.75d | 10.89d | 0d | start no earlier than 2009-03-23 | Wayne | 27h | 20.25h |
| 53 | 3.4 | wire stirrer pumps and switches | 0.89d | 2009-03-26 | 2009-03-26 | 52 |  |  | 10.89d |  | start no earlier than 2009-03-26 | Scott | 8h |  |

Notes:
- 31: Find out what DMO wants to use to FIND the ESP once it's over the side

| ID | WBS | Task | Duration | Start | Finish | Predecessors | Complete | Remaining | Total slack | Free slack | Constraint | Resources | Work | Actual work |
| --- | --- | --- | --- | --- | --- | --- | --- | --- | --- | --- | --- | --- | --- | --- |
| 54 | 3.5 | **install** | 4d | 2009-03-23 A | 2009-03-30 |  | 32% | 2.7d | 10.78d |  |  |  | 88.5h | 28.75h |
| 55 | 3.5.1 | order extra Swageloc | 9h | 2009-03-26 | 2009-03-30 |  |  |  | 10.78d |  | start no earlier than 2009-03-26 | Doug | 9h |  |
| 56 | 3.5.2 | Min-K's & wiring | 3d | 2009-03-23 A | 2009-03-26 A |  | 100% |  |  |  | start no earlier than 2009-03-23 | Scott | 27h | 27h |
| 57 | 3.5.3 | water sensors | 8.5h | 2009-03-26 | 2009-03-26 | 65, 56 |  |  | 10.83d |  | start no earlier than 2009-03-26 | Scott | 8.5h |  |
| 58 | 3.5.4 | cap all ports | 9h | 2009-03-25 | 2009-03-26 | 56FS-8h |  |  | 10.89d | 0d | start no earlier than 2009-03-25 | Doug | 9h |  |
| 59 | 3.5.5 | put DWSM into base bells (no bags) | 7h | 2009-03-26 A | 2009-03-26 | 58 | 25% | 5.25h | 10.89d |  | start no earlier than 2009-03-25 | Doug | 7h | 1.75h |
| 60 | 3.5.6 | He leak test | 7h | 2009-03-26 | 2009-03-26 | 58 |  |  | 10.89d |  | start no earlier than 2009-03-25 | Doug | 7h |  |
| 61 | 3.5.7 | water lines to the bags | 7h | 2009-03-26 | 2009-03-26 | 58 |  |  | 10.89d |  | start no earlier than 2009-03-25 | Doug | 7h |  |
| 62 | 3.5.8 | install bag assembly & air compensator | 7h | 2009-03-26 | 2009-03-26 | 58 |  |  | 10.89d |  | start no earlier than 2009-03-25 | Doug | 7h |  |
| 63 | 3.5.9 | fill w/oil and vent air | 7h | 2009-03-26 | 2009-03-26 | 58 |  |  | 10.89d |  | start no earlier than 2009-03-25 | Doug | 7h |  |
| 64 | 3.6 | **test** | 8.83d? | 2009-03-20 A | 2009-04-02 |  | 21% | 6.96d? | 6.89d |  |  |  | 155.47h | 33.01h |
| 65 | 3.6.1 | pressure & cold test fittings & valves | 0.89d? | 2009-03-20 A | 2009-03-20 A |  | 100% |  |  |  | start no earlier than 2009-03-20 | Doug | 8h | 8h |
| 66 | 3.6.2 | tighten sample can swagloc | 0.89d? | 2009-03-20 A | 2009-03-20 A |  | 100% |  |  |  | start no earlier than 2009-03-20 | Doug | 8h | 8h |
| 67 | 3.6.3 | close HP motor and test sensor position | 1.89d | 2009-03-20 A | 2009-03-26 A | 56 | 100% |  |  |  | start no earlier than 2009-03-20 | Doug | 17.01h | 17.01h |
| 68 | 3.6.4 | I2C connection b/w cans | 0.94d? | 2009-03-26 | 2009-03-26 |  |  |  | 10.84d |  | start no earlier than 2009-03-26 | Scott | 8.46h |  |
| 69 | 3.6.5 | He leak test oil bell (both) | 1d? | 2009-03-25 | 2009-03-26 |  |  |  | 7d | 0.11d | finish no earlier than 2009-03-26 | Doug | 9h |  |
| 70 | 3.6.6 | fill w/ oil and seal cans | 1d? | 2009-03-30 | 2009-03-31 | 69 |  |  | 6.89d | 0d | start no earlier than 2009-03-30 | Doug | 9h |  |
| 71 | 3.6.7 | Brent comes in for initial DWSM running | 1d? | 2009-03-31 | 2009-04-01 | 70 |  |  | 8.78d |  | start no earlier than 2009-03-31 | Brent | 9h |  |
| 72 | 3.6.8 | fill and empty bags | 2.89d? | 2009-03-31 | 2009-04-02 | 70 |  |  | 6.89d |  | start no earlier than 2009-03-31 | Doug | 26h |  |
| 73 | 3.6.9 | 100 psi operational test | 9h | 2009-03-31 | 2009-04-01 | 70 |  |  | 8.78d |  | start no earlier than 2009-03-31 | Doug | 9h |  |
| 74 | 3.6.10 | can we maintain differential pressure | 2.89d? | 2009-03-31 | 2009-04-02 | 70 |  |  | 6.89d |  | start no earlier than 2009-03-31 | Doug | 26h |  |
| 75 | 3.6.11 | segmented high pressure test | 2.89d? | 2009-03-31 | 2009-04-02 | 70 |  |  | 6.89d |  | start no earlier than 2009-03-31 | Doug | 26h |  |
| 76 | 4 | **Elevator Integration stuff** | 1.94d? | 2009-04-03 | 2009-04-07 |  |  |  | 0d |  |  |  | 51.47h |  |
| 77 | 4.1 | mount sphere to elevator assembly | 0.89d? | 2009-04-03 | 2009-04-03 |  |  |  | 0d |  | must finish on 2009-04-03 | Doug | 8h |  |
| 78 | 4.2 | Mount DWSM to Elevator | 0.83d | 2009-04-03 | 2009-04-03 | 28, 29 |  |  | 0.95d |  | start no earlier than 2009-03-31 | Doug | 7.47h |  |
| 79 | 4.3 | install plumbing | 1d? | 2009-04-03 | 2009-04-06 |  |  |  | 5.83d |  | start no earlier than 2009-04-03 | Doug | 9h |  |
| 80 | 4.4 | install cabling | 1d? | 2009-04-03 | 2009-04-06 |  |  |  | 5.83d |  | start no earlier than 2009-04-03 | Scott | 9h |  |
| 81 | 4.5 | weight and balance | 1d? | 2009-04-06 | 2009-04-07 | 2 |  |  | 4.89d |  | start no earlier than 2009-04-06 | Doug | 9h |  |
| 82 | 4.6 | pre-test of DWSM--is it still alive? | 1d? | 2009-04-06 | 2009-04-07 | 21 |  |  | -0.11d | 0d | start no earlier than 2009-04-06 | Brent | 9h |  |

| ID | WBS | Task | Duration | Start | Finish | Predecessors | Total slack | Free slack | Constraint | Resources | Work |
| --- | --- | --- | --- | --- | --- | --- | --- | --- | --- | --- | --- |
| 83 | 5 | **Test Tank** | 4.05d? | 2009-04-06 | 2009-04-13 | 11, 25, 78 | 0d |  |  | All | 89.92h |
| 84 | 5.1 | weight balance | 1d? | 2009-04-06 | 2009-04-07 | 82 | -0.11d | 0d | must finish on 2009-04-07 | Doug | 9h |
| 85 | 5.2 | drop weight testing | 1d? | 2009-04-06 | 2009-04-07 |  | 0d |  | must finish on 2009-04-07 | doug/mike | 9h |
| 86 | 5.3 | Software Development | 3.94d? | 2009-04-07 | 2009-04-13 | 82, 90 | 0.95d |  | start no earlier than 2009-04-07 | Brent | 35.46h |
| 87 | 6 | **MOB** | 7.89d? | 2009-04-01 | 2009-04-14 |  | 0.89d |  |  |  | 36h |
| 88 | 6.1 | load elevator | 1d? | 2009-04-13 | 2009-04-14 |  | 0.89d |  | start no earlier than 2009-04-13 | All | 9h |
| 89 | 6.2 | Practice ROV plug manipulation | 1d? | 2009-04-06 | 2009-04-07 |  | 4.89d |  | start no earlier than 2009-04-06 | All | 9h |
| 90 | 6.3 | Brent starts ROV comms | 1d? | 2009-04-01 | 2009-04-02 |  | 3.84d | 2.89d | start no earlier than 2009-04-01 | Brent | 9h |
| 91 | 6.4 | check ROV connection | 1d? | 2009-04-13 | 2009-04-14 |  | 0.89d |  | start no earlier than 2009-04-13 | All | 9h |
| 94 | 7 | MOB Lobos for first deployment | 0.89d | 2009-04-14 | 2009-04-14 |  | 0d |  | must finish on 2009-04-14 |  |  |
